# POM Project Part 1

Schedule from MS Project, 2017-01-03 to 2017-07-24, status date 2017-01-03, A marks actual dates.

## Calendars

- Standard: Mon-Fri 08:00-12:00, 13:00-17:00; Sat-Sun off. Exceptions (off unless hours are given): 2017-01-16 (Martin Luther King Day), 2017-05-29 (Memorial Day), 2017-07-04 (4th of July).

## Schedule

| ID | WBS | Task | Type | Duration | Start | Finish | Predecessors | Complete | Remaining | Total slack |
| --- | --- | --- | --- | --- | --- | --- | --- | --- | --- | --- |
| 1 | 1 | POM+ Project | manual | 1d | 2017-01-03 A | 2017-01-03 |  |  | 1d |  |
| 2 | 2 | **R&D product development** |  | 44d | 2017-01-03 A | 2017-03-06 |  | 2% | 43.12d | 0d |
| 3 | 2.1 | Need survey | manual | 20d | 2017-01-03 A | 2017-01-31 |  | 5% | 19d |  |
| 4 | 2.2 | Set product specs | manual | 15d | 2017-01-31 A | 2017-02-20 | 3 |  | 15d |  |
| 5 | 2.3 | Shelf life report | manual | 10d | 2017-02-21 A | 2017-03-06 | 4 |  | 10d |  |
| 6 | 2.4 | Nutrition report | manual | 5d | 2017-02-21 A | 2017-02-27 | 4 |  | 5d |  |
| 7 | 3 | Secure fruit suppliers | manual | 20d | 2017-02-28 A | 2017-03-27 | 5, 6 |  | 20d |  |
| 8 | 4 | **Initial production** |  | 83d | 2017-02-28 | 2017-06-23 |  |  |  | 0d |
| 9 | 4.1 | Equipment rehab | manual | 30d | 2017-02-28 A | 2017-04-10 | 4 |  | 30d |  |
| 10 | 4.2 | Production trials | manual | 15d | 2017-04-10 A | 2017-04-28 | 7, 9 |  | 15d |  |
| 11 | 4.3 | Quality trials | manual | 20d | 2017-05-01 A | 2017-05-26 | 10 |  | 20d |  |
| 12 | 4.4 | Quality metrics | manual | 5d | 2017-05-29 A | 2017-06-02 | 11 |  | 5d |  |
| 13 | 4.5 | Quality training | manual | 15d | 2017-06-05 A | 2017-06-23 | 12 |  | 15d |  |
| 14 | 5 | **Distribution** |  | 45d | 2017-03-07 | 2017-05-08 |  |  |  | 0d |
| 15 | 5.1 | Market testing | manual | 30d | 2017-03-07 A | 2017-04-17 | 5, 6 |  | 30d |  |
| 16 | 5.2 | Package design | manual | 15d | 2017-04-18 A | 2017-05-08 | 15 |  | 15d |  |
| 17 | 5.3 | Select distributors | manual | 25d | 2017-03-07 A | 2017-04-10 | 5, 6 |  | 25d |  |
| 18 | 6 | **Legal** |  | 14d | 2017-05-09 | 2017-05-29 |  |  |  | 0d |
| 19 | 6.1 | Complete FDA certification | manual | 15d | 2017-05-09 A | 2017-05-29 | 7, 15 |  | 15d |  |
| 20 | 6.2 | Register trademark | manual | 5d | 2017-05-09 A | 2017-05-15 | 7, 15 |  | 5d |  |
| 21 | 7 | Prepare product launch | manual | 15d | 2017-07-04 A | 2017-07-24 | 13, 16, 17, 19FS+25d, 20FS+15d |  | 15d |  |
